# BAE Planning général révision 1

Schedule from MS Project, 2010-12-13 to 2012-02-07.
COMPAQ

## Calendars

- Standard: Mon-Fri 09:00-12:00, 14:00-18:00; Sat-Sun off. Exceptions (off unless hours are given): 2011-02-27 09:00-12:00, 14:00-18:00, 2011-03-06 09:00-12:00, 14:00-18:00.

## Resources

| Resource |
| --- |
| 1 bulldozer |
| 1 pelle hydraulique |
| 2 Camions |
| 1 Niveleuse |
| 1 Compacteur |
| 1 Citerne à eau |
| 1 Chargeur |
| 2 Camions, 1 Chargeur |
| 1 Rétro_chargeur, 1 Camion, 1 bétonnière, 2 Coffreurs, 4 MO, 3 Ferrailleurs, 2 Maçons, 4 M.spécialisés |
| , 2 Coffreurs, 4 MO, 3 Ferrailleurs, 2 Maçons, 4 M.spécialisés |
| 1 Rétro_chargeur, 1 Camion, 1 bétonnière |
| 1 Rétro_chargeur, 1 Camion, |
| 1 bétonnière |
| 1 bétonnière, 3 Férrailleurs, 4 MO |
| 1 Bétonnière, 1 Maçon, 4 M.Spécialisés |
| 1 Rétro-chargeur, 2 M.Spécialisés |
| 1 Rétro_chargeur, 1 Camion, 2 Coffreurs, 2 MO |
| 1 Rétro_chargeur, 1 Camion, 2 Coffreurs,1 Maçon, 2 MO |
| ghh |
| 1 Rétro_chargeur, 1 Camion, 8 Coffreurs,1 Maçon, 2 MO |
| 1 Rétro_chargeur, 1 Camion, 8 Coffreurs,4 Maçon, 8 MO |
| 1 Rétro_chargeur, 1 Camion,3 MO |
| 1 Rétro_chargeur, 1 Camion,3 Coffreurs, 1 Maçon, 3 MO |
| 1Pelle hydraulique, 1 Camion,3 Coffreurs, 1 Maçon, 3 MO |
| 1Pelle hydraulique, 1 Camion,10 Coffreurs, 5 Maçon, 5 Ferrailleurs, 8 MO |
| 1Pelle hydraulique, 1 Camion,10 Cof, 5 Maçon, 5 Fer, 8 MO |
| 1Pelle hydraulique, 1 Camion,5 Cof, 2 Maçon, 3 Fer, 3 MO |
| 1 Bétonnière, 2 Cof, 2 Maçons, 3MO |
| 2 Cof, 2 Maçons, 3MO |
| 2 Maçons, 3MO |
| 1 Chargeur, 1 Epandeuse |
| 1 Rétro_chargeur, 1 Camion,1 Cof, 3 MO |

## Schedule

| ID | WBS | Task | Type | Duration | Start | Finish | Predecessors | Baseline start | Baseline finish | Baseline duration | Baseline 1 start | Baseline 1 finish | Total slack | Free slack | Constraint | Resources | Work |
| --- | --- | --- | --- | --- | --- | --- | --- | --- | --- | --- | --- | --- | --- | --- | --- | --- | --- |
| 1 | 1 | **BAE : POSTE 60/10 Kv** |  | 265.25d | 2010-12-13 | 2012-02-07 |  | 2010-12-13 | 2012-01-20 | 255.25d | 2010-12-13 | 2012-01-20 | 0d |  |  |  | 12296h |
| 2 | 1.1 | Mise à disposition du site | milestone | 0d | 2010-12-13 | 2010-12-13 |  | 2010-12-13 | 2010-12-13 | 0d | 2010-12-13 | 2010-12-13 | 265.25d |  |  |  |  |
| 3 | 1.2 | Mobilistation Entreprise GC |  | 12d | 2010-12-13 | 2010-12-30 |  | 2010-12-13 | 2010-12-30 | 12d | 2010-12-13 | 2010-12-30 | 253.25d |  |  |  |  |
| 4 | 1.3 | Remise des plans |  | 90d | 2010-12-13 | 2011-05-02 |  | 2010-12-13 | 2011-05-02 | 90d | 2010-12-13 | 2011-05-02 | 175.25d |  |  |  |  |
| 5 | 1.4 | **INSTALLATION DE CHANTIER** |  | 28d | 2010-12-13 | 2011-01-25 |  | 2010-12-13 | 2011-01-25 | 28d | 2010-12-13 | 2011-01-25 | 237.25d |  |  |  |  |
| 6 | 1.4.1 | Route d'accés aux bureaux |  | 7d | 2010-12-13 | 2010-12-22 |  | 2010-12-13 | 2010-12-22 | 7d | 2010-12-13 | 2010-12-22 | 258.25d |  |  |  |  |
| 7 | 1.4.2 | Clôture de délimitation zones de travail |  | 21d | 2010-12-13 | 2011-01-13 |  | 2010-12-13 | 2011-01-13 | 21d | 2010-12-13 | 2011-01-13 | 244.25d |  |  |  |  |
| 8 | 1.4.3 | Aménagement voies d'accés au chantier |  | 7d | 2010-12-13 | 2010-12-22 |  | 2010-12-13 | 2010-12-22 | 7d | 2010-12-13 | 2010-12-22 | 258.25d |  |  |  |  |
| 9 | 1.4.4 | Aménagement des zones de stockage et de montage |  | 28d | 2010-12-13 | 2011-01-25 |  | 2010-12-13 | 2011-01-25 | 28d | 2010-12-13 | 2011-01-25 | 237.25d |  |  |  |  |
| 10 | 1.5 | Arrêt de chantier,cause: conduites d'eau | milestone | 0d | 2011-01-13 | 2011-01-13 |  | 2011-01-13 | 2011-01-13 | 0d | 2011-01-13 | 2011-01-13 | 245.12d |  | start no earlier than 2011-01-13 |  |  |
| 11 | 1.6 | Rippage de la ligne MT | milestone | 22d | 2010-12-13 | 2011-01-17 |  | 2010-12-13 | 2011-01-17 | 22d | 2010-12-13 | 2011-01-17 | 0d |  | start no later than 2010-12-13 |  |  |
| 12 | 1.7 | Reprise des travaux | milestone | 0d | 2011-02-15 | 2011-02-15 |  | 2011-02-15 | 2011-02-15 | 0d | 2011-02-15 | 2011-02-15 | 111d | 0d | start no earlier than 2011-02-15 |  |  |
| 13 | 1.8 | Formulation du béton | milestone | 0d | 2011-02-27 | 2011-02-27 |  | 2011-02-27 | 2011-02-27 | 0d | 2011-02-27 | 2011-02-27 | 212.12d | 0d | start no earlier than 2011-02-27 |  |  |
| 14 | 1.9 | Approvisionnements |  | 5d | 2011-02-27 | 2011-03-04 | 13 | 2011-02-27 | 2011-03-04 | 5d | 2011-02-27 | 2011-03-04 | 212.12d | 0.25d |  |  |  |
| 15 | 1.10 | Essais de convenance | milestone | 0d | 2011-03-06 | 2011-03-06 | 14 | 2011-03-06 | 2011-03-06 | 0d | 2011-03-06 | 2011-03-06 | 211.88d |  | start no earlier than 2011-03-06 |  |  |
| 16 | 1.11 | **TERRASSEMENTS** |  | 28d | 2011-02-15 | 2011-03-28 | 12 | 2011-02-15 | 2011-03-28 | 28d | 2011-02-15 | 2011-03-28 | 111d | 0d |  |  | 768h |
| 17 | 1.11.1 | Décapage des terres végétales |  | 3d | 2011-02-15 | 2011-02-18 |  | 2011-02-15 | 2011-02-17 | 2.33d | 2011-02-15 | 2011-02-17 | 111d | 0d |  | 2 Camions; 1 bulldozer; 1 Chargeur | 72h |
| 18 | 1.11.2 | Déblais |  | 10d | 2011-02-16 | 2011-03-02 | 17SS+1d | 2011-02-16 | 2011-03-02 | 10d | 2011-02-16 | 2011-03-02 | 111d | 0d |  | 2 Camions; 1 bulldozer; 1 pelle hydraulique | 240h |
| 19 | 1.11.3 | Remblais |  | 5d | 2011-03-02 | 2011-03-09 | 18 | 2011-03-02 | 2011-03-24 | 15d | 2011-03-02 | 2011-03-24 | 111d | 0d |  | 2 Camions; 1 pelle hydraulique; 1 Niveleuse | 120h |
| 20 | 1.11.4 | Compactages |  | 16d | 2011-03-03 | 2011-03-28 | 19SS+1d | 2011-03-03 | 2011-03-28 | 16d | 2011-03-03 | 2011-03-28 | 111d |  |  | 1 Citerne à eau; 1 Compacteur | 256h |
| 21 | 1.11.5 | Evacuation |  | 10d | 2011-02-16 | 2011-03-02 | 18SS | 2011-02-16 | 2011-03-02 | 10d | 2011-02-16 | 2011-03-02 | 128d |  |  | 2 Camions, 1 Chargeur | 80h |
| 22 | 1.12 | **CLOTURES, LOGE & GUERITES** |  | 100d | 2011-03-07 | 2011-08-12 | 16FS-14d | 2011-03-07 | 2011-08-12 | 100d | 2011-03-07 | 2011-08-12 | 111d | 0d |  |  | 3288h |
| 23 | 1.12.1 | **Clôture** |  | 100d | 2011-03-07 | 2011-08-12 | 18 | 2011-03-07 | 2011-08-12 | 100d | 2011-03-07 | 2011-08-12 | 111d | 0d |  |  | 2168h |
| 24 | 1.12.1.1 | Fouilles en tranchée et BP |  | 50d | 2011-03-07 | 2011-05-25 |  | 2011-03-07 | 2011-05-25 | 50d | 2011-03-07 | 2011-05-25 | 111d | 0d |  | 1 Rétro_chargeur, 1 Camion, | 400h |
| 25 | 1.12.1.2 | Semelles, amorces poteaux et longrines |  | 56d | 2011-03-10 | 2011-06-08 | 24SS+3d | 2011-03-10 | 2011-06-08 | 56d | 2011-03-10 | 2011-06-08 | 111d | 0d |  | 1 bétonnière, 3 Férrailleurs, 4 MO | 448h |
| 26 | 1.12.1.3 | Coulage dalettes et poteaux (Panneaux) |  | 75d | 2011-03-10 | 2011-07-08 | 25SS | 2011-03-10 | 2011-07-08 | 75d | 2011-03-10 | 2011-07-08 | 111d | 0d |  | 1 Bétonnière, 1 Maçon, 4 M.Spécialisés | 600h |
| 27 | 1.12.1.4 | Montage clôture en béton, et coulage chaînage |  | 90d | 2011-03-22 | 2011-08-12 | 26SS+7d | 2011-03-22 | 2011-08-12 | 90d | 2011-03-22 | 2011-08-12 | 111d |  |  | 1 Rétro-chargeur, 2 M.Spécialisés | 720h |

| ID | WBS | Task | Duration | Start | Finish | Predecessors | Baseline start | Baseline finish | Baseline duration | Baseline 1 start | Baseline 1 finish | Total slack | Free slack | Resources | Work |
| --- | --- | --- | --- | --- | --- | --- | --- | --- | --- | --- | --- | --- | --- | --- | --- |
| 28 | 1.12.2 | **Guérites** | 60d | 2011-03-07 | 2011-06-09 | 23SS | 2011-03-07 | 2011-06-09 | 60d | 2011-03-07 | 2011-06-09 | 151d | 0d | 1 Rétro_chargeur, 1 Camion, 2 Coffreurs, 2 MO | 480h |
| 29 | 1.12.2.1 | Terrassement + BP | 5d | 2011-03-07 | 2011-03-14 |  | 2011-03-07 | 2011-03-14 | 5d | 2011-03-07 | 2011-03-14 | 151d | 0d |  |  |
| 30 | 1.12.2.2 | Fondations | 10d | 2011-03-14 | 2011-03-30 | 29 | 2011-03-14 | 2011-03-30 | 10d | 2011-03-14 | 2011-03-30 | 151d | 0d |  |  |
| 31 | 1.12.2.3 | Dallage | 5d | 2011-03-30 | 2011-04-06 | 30 | 2011-03-30 | 2011-04-06 | 5d | 2011-03-30 | 2011-04-06 | 151d | 0d |  |  |
| 32 | 1.12.2.4 | Elevation | 10d | 2011-04-06 | 2011-04-22 | 31 | 2011-04-06 | 2011-04-22 | 10d | 2011-04-06 | 2011-04-22 | 151d | 0d |  |  |
| 33 | 1.12.2.5 | Dalle | 5d | 2011-04-22 | 2011-04-29 | 32 | 2011-04-22 | 2011-04-29 | 5d | 2011-04-22 | 2011-04-29 | 151d | 0d |  |  |
| 34 | 1.12.2.6 | Finitions | 15d | 2011-05-02 | 2011-05-25 | 33 | 2011-05-02 | 2011-05-25 | 15d | 2011-05-02 | 2011-05-25 | 151d | 0d |  |  |
| 35 | 1.12.2.7 | Etanchéité | 5d | 2011-05-25 | 2011-06-01 | 34 | 2011-05-25 | 2011-06-01 | 5d | 2011-05-25 | 2011-06-01 | 151d | 0d |  |  |
| 36 | 1.12.2.8 | Réseaux AEP, EP | 5d | 2011-06-01 | 2011-06-09 | 35 | 2011-06-01 | 2011-06-09 | 5d | 2011-06-01 | 2011-06-09 | 151d |  |  |  |
| 37 | 1.12.3 | **LOGE DE GARDIENNAGE** | 80d | 2011-03-07 | 2011-07-12 | 28SS | 2011-03-07 | 2011-07-12 | 80d | 2011-03-07 | 2011-07-12 | 131d |  | 1 Rétro_chargeur, 1 Camion, 2 Coffreurs,1 Maçon, 2 MO | 640h |
| 38 | 1.12.3.1 | Terrassement + BP | 5d | 2011-03-07 | 2011-03-14 |  | 2011-03-07 | 2011-03-14 | 5d | 2011-03-07 | 2011-03-14 | 131d | 0d |  |  |
| 39 | 1.12.3.2 | Fondations | 15d | 2011-03-14 | 2011-04-06 | 38 | 2011-03-14 | 2011-04-06 | 15d | 2011-03-14 | 2011-04-06 | 131d | 0d |  |  |
| 40 | 1.12.3.3 | Dallage | 10d | 2011-04-06 | 2011-04-22 | 39 | 2011-04-06 | 2011-04-22 | 10d | 2011-04-06 | 2011-04-22 | 131d | 0d |  |  |
| 41 | 1.12.3.4 | Elevation | 15d | 2011-04-22 | 2011-05-17 | 40 | 2011-04-22 | 2011-05-17 | 15d | 2011-04-22 | 2011-05-17 | 131d | 0d |  |  |
| 42 | 1.12.3.5 | Dalle | 10d | 2011-05-17 | 2011-06-01 | 41 | 2011-05-17 | 2011-06-01 | 10d | 2011-05-17 | 2011-06-01 | 131d | 0d |  |  |
| 43 | 1.12.3.6 | Finitions | 15d | 2011-06-01 | 2011-06-24 | 42 | 2011-06-01 | 2011-06-24 | 15d | 2011-06-01 | 2011-06-24 | 131d | 0d |  |  |
| 44 | 1.12.3.7 | Etanchéité | 5d | 2011-06-27 | 2011-07-04 | 43 | 2011-06-27 | 2011-07-04 | 5d | 2011-06-27 | 2011-07-04 | 131d | 0d |  |  |
| 45 | 1.12.3.8 | Réseaux AEP, EP | 5d | 2011-07-04 | 2011-07-12 | 44 | 2011-07-04 | 2011-07-12 | 5d | 2011-07-04 | 2011-07-12 | 131d |  |  |  |
| 46 | 1.13 | **MASSIFS** | 128d | 2011-03-29 | 2011-10-19 | 22SS+14d | 2011-03-29 | 2011-10-19 | 128d | 2011-03-29 | 2011-10-19 | 69d | 0d | 1 Rétro_chargeur, 1 Camion, 8 Coffreurs,4 Maçon, 8 MO | 1024h |
| 47 | 1.13.1 | **Portiques** | 62d | 2011-03-29 | 2011-07-05 |  | 2011-03-29 | 2011-07-05 | 62d | 2011-03-29 | 2011-07-05 | 135d |  |  |  |
| 48 | 1.13.1.1 | Travée R.P.E 2 | 27d | 2011-03-29 | 2011-05-10 |  | 2011-03-29 | 2011-05-10 | 27d | 2011-03-29 | 2011-05-10 | 135d | 0d |  |  |
| 49 | 1.13.1.2 | Travée Couplage | 27d | 2011-04-05 | 2011-05-18 | 48SS+5d | 2011-04-05 | 2011-05-18 | 27d | 2011-04-05 | 2011-05-18 | 135d | 0d |  |  |
| 50 | 1.13.1.3 | Travée TR 03 | 27d | 2011-04-13 | 2011-05-26 | 49SS+5d | 2011-04-13 | 2011-05-26 | 27d | 2011-04-13 | 2011-05-26 | 135d | 0d |  |  |
| 51 | 1.13.1.4 | Travée BATNA II | 27d | 2011-04-21 | 2011-06-02 | 50SS+5d | 2011-04-21 | 2011-06-02 | 27d | 2011-04-21 | 2011-06-02 | 135d | 0d |  |  |
| 52 | 1.13.1.5 | Travée TR.02 | 27d | 2011-04-28 | 2011-06-10 | 51SS+5d | 2011-04-28 | 2011-06-10 | 27d | 2011-04-28 | 2011-06-10 | 135d | 0d |  |  |
| 53 | 1.13.1.6 | Travée BATNA I | 27d | 2011-05-06 | 2011-06-20 | 52SS+5d | 2011-05-06 | 2011-06-20 | 27d | 2011-05-06 | 2011-06-20 | 135d | 0d |  |  |
| 54 | 1.13.1.7 | Travée TR.01 | 27d | 2011-05-16 | 2011-06-28 | 53SS+5d | 2011-05-16 | 2011-06-28 | 27d | 2011-05-16 | 2011-06-28 | 135d | 0d |  |  |
| 55 | 1.13.1.8 | Travée R.P.E 1 | 27d | 2011-05-24 | 2011-07-05 | 54SS+5d | 2011-05-24 | 2011-07-05 | 27d | 2011-05-24 | 2011-07-05 | 135d |  |  |  |

| ID | WBS | Task | Duration | Start | Finish | Predecessors | Baseline start | Baseline finish | Baseline duration | Baseline 1 start | Baseline 1 finish | Total slack | Free slack | Resources | Work |
| --- | --- | --- | --- | --- | --- | --- | --- | --- | --- | --- | --- | --- | --- | --- | --- |
| 56 | 1.13.2 | **Supports** | 128d | 2011-03-29 | 2011-10-19 |  | 2011-03-29 | 2011-10-19 | 128d | 2011-03-29 | 2011-10-19 | 69d |  |  |  |
| 57 | 1.13.2.1 | Terrassement et BP | 24d | 2011-03-29 | 2011-05-05 |  | 2011-03-29 | 2011-05-05 | 24d | 2011-03-29 | 2011-05-05 | 69d | 0d |  |  |
| 58 | 1.13.2.2 | Coulage semelles | 48d | 2011-04-25 | 2011-07-11 | 57FS-7d | 2011-04-25 | 2011-07-11 | 48d | 2011-04-25 | 2011-07-11 | 69d | 0d |  |  |
| 59 | 1.13.2.3 | Coulage fûts y/c pose tiges d'ancrage | 64d | 2011-06-29 | 2011-10-10 | 58FS-7d | 2011-06-29 | 2011-10-10 | 64d | 2011-06-29 | 2011-10-10 | 69d | 0d |  |  |
| 60 | 1.13.2.4 | Badigeon et Remblais | 14d | 2011-09-27 | 2011-10-19 | 59FS-8d | 2011-09-27 | 2011-10-19 | 14d | 2011-09-27 | 2011-10-19 | 69d |  |  |  |
| 61 | 1.14 | **RESEAU DE TERRE** | 85d | 2011-04-20 | 2011-09-02 | 46SS+14d | 2011-04-20 | 2011-09-02 | 85d | 2011-04-20 | 2011-09-02 | 98d | 0d | 1 Rétro_chargeur, 1 Camion,3 MO | 680h |
| 62 | 1.14.1 | Fouille en tranchée | 30d | 2011-04-20 | 2011-06-07 |  | 2011-04-20 | 2011-06-07 | 30d | 2011-04-20 | 2011-06-07 | 98d | 0d |  |  |
| 63 | 1.14.2 | Pose câble | 60d | 2011-05-26 | 2011-08-30 | 62FS-7d | 2011-05-26 | 2011-08-30 | 60d | 2011-05-26 | 2011-08-30 | 98d | 0d |  |  |
| 64 | 1.14.3 | Avertisseur et remblais | 30d | 2011-07-15 | 2011-09-02 | 63FS-28d | 2011-07-15 | 2011-09-02 | 30d | 2011-07-15 | 2011-09-02 | 98d |  |  |  |
| 65 | 1.15 | **DRAINAGE, AEP ET ASSAINISSEMENT** | 60d | 2011-05-12 | 2011-08-16 | 61SS+14d | 2011-05-12 | 2011-08-16 | 60d | 2011-05-12 | 2011-08-16 | 109d |  | 1 Rétro_chargeur, 1 Camion,3 Coffreurs, 1 Maçon, 3 MO | 480h |
| 66 | 1.15.1 | Drainage | 60d | 2011-05-12 | 2011-08-16 |  | 2011-05-12 | 2011-08-16 | 60d | 2011-05-12 | 2011-08-16 | 109d |  |  |  |
| 67 | 1.15.2 | BACHE A EAU | 20d | 2011-05-12 | 2011-06-13 |  | 2011-05-12 | 2011-06-13 | 20d | 2011-05-12 | 2011-06-13 | 139d | 0d |  |  |
| 68 | 1.15.3 | FOSSE SEPTIQUE | 30d | 2011-05-12 | 2011-06-29 |  | 2011-05-12 | 2011-06-29 | 30d | 2011-05-12 | 2011-06-29 | 139d |  |  |  |
| 69 | 1.15.4 | AMENEE D'EAU | 10d | 2011-06-13 | 2011-06-29 | 67 | 2011-06-13 | 2011-06-29 | 10d | 2011-06-13 | 2011-06-29 | 139d |  |  |  |
| 70 | 1.16 | **BATIMENTS** | 173d | 2011-03-17 | 2011-12-19 | 22SS+7d | 2011-03-17 | 2011-12-19 | 173d | 2011-03-17 | 2011-12-19 | 31d | 0d | 1Pelle hydraulique, 1 Camion,5 Cof, 2 Maçon, 3 Fer, 3 MO | 1384h |
| 71 | 1.16.1 | **BATIMENT MT** | 13.17w | 2011-03-17 | 2011-07-21 |  | 2011-03-17 | 2011-07-21 | 13.17w | 2011-03-17 | 2011-07-21 | 31d | 0d |  |  |
| 72 | 1.16.1.1 | **Gros œuvre** | 50d | 2011-03-17 | 2011-06-06 |  | 2011-03-17 | 2011-06-06 | 50d | 2011-03-17 | 2011-06-06 | 31d |  |  |  |
| 73 | 1.16.1.1.1 | **Fondations** | 15d | 2011-03-17 | 2011-04-11 |  | 2011-03-17 | 2011-04-11 | 15d | 2011-03-17 | 2011-04-11 | 31d | 0d |  |  |
| 74 | 1.16.1.1.1.1 | Terrassement et BP | 9d | 2011-03-17 | 2011-03-31 |  | 2011-03-17 | 2011-03-31 | 9d | 2011-03-17 | 2011-03-31 | 31d | 0d |  |  |
| 75 | 1.16.1.1.1.2 | Ferraillage | 9d | 2011-03-21 | 2011-04-04 | 74SS+2d | 2011-03-21 | 2011-04-04 | 9d | 2011-03-21 | 2011-04-04 | 31d | 0d |  |  |
| 76 | 1.16.1.1.1.3 | Coffrage | 9d | 2011-03-23 | 2011-04-06 | 75SS+2d | 2011-03-23 | 2011-04-06 | 9d | 2011-03-23 | 2011-04-06 | 31d | 0d |  |  |
| 77 | 1.16.1.1.1.4 | Bétonnage | 9d | 2011-03-25 | 2011-04-11 | 76SS+2d | 2011-03-25 | 2011-04-11 | 9d | 2011-03-25 | 2011-04-11 | 31d |  |  |  |
| 78 | 1.16.1.1.2 | **Elevation** | 12d | 2011-04-11 | 2011-04-28 | 73 | 2011-04-11 | 2011-04-28 | 12d | 2011-04-11 | 2011-04-28 | 31d | 0d |  |  |
| 79 | 1.16.1.1.2.1 | Ferraillage | 10d | 2011-04-11 | 2011-04-26 |  | 2011-04-11 | 2011-04-26 | 10d | 2011-04-11 | 2011-04-26 | 31d | 0d |  |  |
| 80 | 1.16.1.1.2.2 | Coffrage | 10d | 2011-04-13 | 2011-04-28 | 79SS+2d | 2011-04-13 | 2011-04-28 | 10d | 2011-04-13 | 2011-04-28 | 31d | 0d |  |  |
| 81 | 1.16.1.1.2.3 | Pose des tiges d'ancrage | 2d | 2011-04-15 | 2011-04-19 | 80SS+2d | 2011-04-15 | 2011-04-19 | 2d | 2011-04-15 | 2011-04-19 | 32d | 0d |  |  |
| 82 | 1.16.1.1.2.4 | Bétonnage | 5d | 2011-04-20 | 2011-04-27 | 81 | 2011-04-20 | 2011-04-27 | 5d | 2011-04-20 | 2011-04-27 | 32d |  |  |  |

| ID | WBS | Task | Duration | Start | Finish | Predecessors | Baseline start | Baseline finish | Baseline duration | Baseline 1 start | Baseline 1 finish | Total slack | Free slack |
| --- | --- | --- | --- | --- | --- | --- | --- | --- | --- | --- | --- | --- | --- |
| 83 | 1.16.1.1.3 | **Dalle** | 14d | 2011-04-28 | 2011-05-20 | 78 | 2011-04-28 | 2011-05-20 | 14d | 2011-04-28 | 2011-05-20 | 31d | 0d |
| 84 | 1.16.1.1.3.1 | Coffrage | 10d | 2011-04-28 | 2011-05-16 |  | 2011-04-28 | 2011-05-16 | 10d | 2011-04-28 | 2011-05-16 | 31d | 0d |
| 85 | 1.16.1.1.3.2 | Ferraillage | 10d | 2011-05-04 | 2011-05-19 | 84SS+3d | 2011-05-04 | 2011-05-19 | 10d | 2011-05-04 | 2011-05-19 | 31d | 0d |
| 86 | 1.16.1.1.3.3 | Bétonnage | 1d | 2011-05-19 | 2011-05-20 | 85 | 2011-05-19 | 2011-05-20 | 1d | 2011-05-19 | 2011-05-20 | 31d |  |
| 87 | 1.16.1.1.4 | **Dallage du vide technique** | 9d | 2011-05-20 | 2011-06-06 | 83 | 2011-05-20 | 2011-06-06 | 9d | 2011-05-20 | 2011-06-06 | 31d | 0d |
| 88 | 1.16.1.1.4.1 | Terrassement et polyane | 5d | 2011-05-20 | 2011-05-30 |  | 2011-05-20 | 2011-05-30 | 5d | 2011-05-20 | 2011-05-30 | 31d | 0d |
| 89 | 1.16.1.1.4.2 | Ferraillage | 3d | 2011-05-30 | 2011-06-02 | 88 | 2011-05-30 | 2011-06-02 | 3d | 2011-05-30 | 2011-06-02 | 31d | 0d |
| 90 | 1.16.1.1.4.3 | Bétonnage | 1d | 2011-06-03 | 2011-06-06 | 89 | 2011-06-03 | 2011-06-06 | 1d | 2011-06-03 | 2011-06-06 | 31d |  |
| 91 | 1.16.1.2 | **C.E.S** | 29d | 2011-06-06 | 2011-07-21 | 87 | 2011-06-06 | 2011-07-21 | 29d | 2011-06-06 | 2011-07-21 | 31d |  |
| 92 | 1.16.1.2.1 | Pose des rails HALFEN | 3d | 2011-06-06 | 2011-06-09 |  | 2011-06-06 | 2011-06-09 | 3d | 2011-06-06 | 2011-06-09 | 31d | 0d |
| 93 | 1.16.1.2.2 | Finitions verticales | 15d | 2011-06-09 | 2011-07-04 | 92 | 2011-06-09 | 2011-07-04 | 15d | 2011-06-09 | 2011-07-04 | 31d | 0d |
| 94 | 1.16.1.2.3 | Finitions horizontales | 15d | 2011-06-15 | 2011-07-08 | 93SS+3d | 2011-06-15 | 2011-07-08 | 15d | 2011-06-15 | 2011-07-08 | 31d | 0d |
| 95 | 1.16.1.2.4 | Métallerie, menuiserie | 15d | 2011-06-22 | 2011-07-15 | 94SS+5d | 2011-06-22 | 2011-07-15 | 15d | 2011-06-22 | 2011-07-15 | 34d |  |
| 96 | 1.16.1.2.5 | Plomberie sanitaire | 15d | 2011-06-28 | 2011-07-21 | 94FS-7d | 2011-06-28 | 2011-07-21 | 15d | 2011-06-28 | 2011-07-21 | 31d |  |
| 97 | 1.16.2 | **BATIMENT HT** | 72d | 2011-05-02 | 2011-08-24 | 71SS+28d | 2011-05-02 | 2011-08-24 | 72d | 2011-05-02 | 2011-08-24 | 60d | 0d |
| 98 | 1.16.2.1 | **Gros œuvre** | 54d | 2011-05-02 | 2011-07-26 |  | 2011-05-02 | 2011-07-26 | 54d | 2011-05-02 | 2011-07-26 | 60d | 0d |
| 99 | 1.16.2.1.1 | **Fondations** | 16d | 2011-05-02 | 2011-05-26 |  | 2011-05-02 | 2011-05-26 | 16d | 2011-05-02 | 2011-05-26 | 60d | 0d |
| 100 | 1.16.2.1.1.1 | Terrassement et BP | 5d | 2011-05-02 | 2011-05-09 |  | 2011-05-02 | 2011-05-09 | 5d | 2011-05-02 | 2011-05-09 | 60d | 0d |
| 101 | 1.16.2.1.1.2 | Ferraillage | 10d | 2011-05-04 | 2011-05-19 | 100SS+2d | 2011-05-04 | 2011-05-19 | 10d | 2011-05-04 | 2011-05-19 | 60d | 0d |
| 102 | 1.16.2.1.1.3 | Coffrage | 10d | 2011-05-06 | 2011-05-23 | 101SS+2d | 2011-05-06 | 2011-05-23 | 10d | 2011-05-06 | 2011-05-23 | 60d | 0d |
| 103 | 1.16.2.1.1.4 | Bétonnage | 10d | 2011-05-10 | 2011-05-26 | 102SS+2d | 2011-05-10 | 2011-05-26 | 10d | 2011-05-10 | 2011-05-26 | 60d |  |
| 104 | 1.16.2.1.2 | **Elevation** | 21d | 2011-05-26 | 2011-06-29 | 99 | 2011-05-26 | 2011-06-29 | 21d | 2011-05-26 | 2011-06-29 | 60d | 0d |
| 105 | 1.16.2.1.2.1 | Ferraillage | 15d | 2011-05-26 | 2011-06-20 |  | 2011-05-26 | 2011-06-20 | 15d | 2011-05-26 | 2011-06-20 | 60d | 0d |
| 106 | 1.16.2.1.2.2 | Coffrage | 15d | 2011-05-30 | 2011-06-22 | 105SS+2d | 2011-05-30 | 2011-06-22 | 15d | 2011-05-30 | 2011-06-22 | 60d | 0d |
| 107 | 1.16.2.1.2.3 | Pose des tiges d'ancrage | 2d | 2011-06-01 | 2011-06-06 | 106SS+2d | 2011-06-01 | 2011-06-06 | 2d | 2011-06-01 | 2011-06-06 | 60d | 0d |
| 108 | 1.16.2.1.2.4 | Bétonnage | 15d | 2011-06-06 | 2011-06-29 | 107 | 2011-06-06 | 2011-06-29 | 15d | 2011-06-06 | 2011-06-29 | 60d |  |

| ID | WBS | Task | Duration | Start | Finish | Predecessors | Baseline start | Baseline finish | Baseline duration | Baseline 1 start | Baseline 1 finish | Total slack | Free slack |
| --- | --- | --- | --- | --- | --- | --- | --- | --- | --- | --- | --- | --- | --- |
| 109 | 1.16.2.1.3 | **Dalle** | 17d | 2011-06-29 | 2011-07-26 | 104 | 2011-06-29 | 2011-07-26 | 17d | 2011-06-29 | 2011-07-26 | 60d |  |
| 110 | 1.16.2.1.3.1 | Coffrage | 10d | 2011-06-29 | 2011-07-14 |  | 2011-06-29 | 2011-07-14 | 10d | 2011-06-29 | 2011-07-14 | 60d | 0d |
| 111 | 1.16.2.1.3.2 | Ferraillage | 10d | 2011-07-04 | 2011-07-20 | 110SS+3d | 2011-07-04 | 2011-07-20 | 10d | 2011-07-04 | 2011-07-20 | 60d | 0d |
| 112 | 1.16.2.1.3.3 | Pose rails et cornières | 3d | 2011-07-20 | 2011-07-25 | 111 | 2011-07-20 | 2011-07-25 | 3d | 2011-07-20 | 2011-07-25 | 60d | 0d |
| 113 | 1.16.2.1.3.4 | Bétonnage | 1d | 2011-07-25 | 2011-07-26 | 112 | 2011-07-25 | 2011-07-26 | 1d | 2011-07-25 | 2011-07-26 | 60d |  |
| 114 | 1.16.2.2 | **C.E.S** | 18d | 2011-07-26 | 2011-08-24 | 98 | 2011-07-26 | 2011-08-24 | 18d | 2011-07-26 | 2011-08-24 | 60d |  |
| 115 | 1.16.2.2.1 | Finitions verticales | 10d | 2011-07-26 | 2011-08-11 |  | 2011-07-26 | 2011-08-11 | 10d | 2011-07-26 | 2011-08-11 | 60d | 0d |
| 116 | 1.16.2.2.2 | Finitions horizontales | 10d | 2011-08-01 | 2011-08-16 | 115SS+3d | 2011-08-01 | 2011-08-16 | 10d | 2011-08-01 | 2011-08-16 | 60d | 0d |
| 117 | 1.16.2.2.3 | Métallerie, menuiserie | 10d | 2011-08-08 | 2011-08-24 | 116SS+5d | 2011-08-08 | 2011-08-24 | 10d | 2011-08-08 | 2011-08-24 | 60d |  |
| 118 | 1.16.2.2.4 | Plomberie sanitaire | 10d | 2011-08-04 | 2011-08-19 | 116FS-7d | 2011-08-04 | 2011-08-19 | 10d | 2011-08-04 | 2011-08-19 | 62d |  |
| 119 | 1.16.3 | **BATIMENTS DE RELAYAGES** | 20.33w | 2011-06-07 | 2011-12-19 | 71FS-28d | 2011-06-07 | 2011-12-19 | 20.33w | 2011-06-07 | 2011-12-19 | 31d |  |
| 120 | 1.16.3.1 | BR 01 | 30d | 2011-06-07 | 2011-07-25 |  | 2011-06-07 | 2011-07-25 | 30d | 2011-06-07 | 2011-07-25 | 31d | 0d |
| 121 | 1.16.3.2 | BR 02 | 30d | 2011-07-13 | 2011-08-30 | 120FS-7d | 2011-07-13 | 2011-08-30 | 30d | 2011-07-13 | 2011-08-30 | 31d | 0d |
| 122 | 1.16.3.3 | BR 03 | 30d | 2011-08-18 | 2011-10-06 | 121FS-7d | 2011-08-18 | 2011-10-06 | 30d | 2011-08-18 | 2011-10-06 | 31d | 0d |
| 123 | 1.16.3.4 | BR 04 | 30d | 2011-09-26 | 2011-11-11 | 122FS-7d | 2011-09-26 | 2011-11-11 | 30d | 2011-09-26 | 2011-11-11 | 31d | 0d |
| 124 | 1.16.3.5 | BR 05 | 30d | 2011-11-01 | 2011-12-19 | 123FS-7d | 2011-11-01 | 2011-12-19 | 30d | 2011-11-01 | 2011-12-19 | 31d |  |
| 125 | 1.16.4 | **LOCAL Groupe Eléctrogène** | 62d | 2011-07-26 | 2011-11-02 | 97FS-18d | 2011-07-26 | 2011-11-02 | 62d | 2011-07-26 | 2011-11-02 | 60d |  |
| 126 | 1.16.4.1 | Terrassement et BP | 2d | 2011-07-26 | 2011-07-28 |  | 2011-07-26 | 2011-07-28 | 2d | 2011-07-26 | 2011-07-28 | 60d | 0d |
| 127 | 1.16.4.2 | Fondations | 10d | 2011-07-29 | 2011-08-15 | 126 | 2011-07-29 | 2011-08-15 | 10d | 2011-07-29 | 2011-08-15 | 60d | 0d |
| 128 | 1.16.4.3 | Dallage | 10d | 2011-08-15 | 2011-08-30 | 127 | 2011-08-15 | 2011-08-30 | 10d | 2011-08-15 | 2011-08-30 | 60d | 0d |
| 129 | 1.16.4.4 | Elevation | 10d | 2011-08-30 | 2011-09-15 | 128 | 2011-08-30 | 2011-09-15 | 10d | 2011-08-30 | 2011-09-15 | 60d | 0d |
| 130 | 1.16.4.5 | Dalle | 10d | 2011-09-15 | 2011-09-30 | 129 | 2011-09-15 | 2011-09-30 | 10d | 2011-09-15 | 2011-09-30 | 60d | 0d |
| 131 | 1.16.4.6 | Finitions | 10d | 2011-09-30 | 2011-10-18 | 130 | 2011-09-30 | 2011-10-18 | 10d | 2011-09-30 | 2011-10-18 | 60d | 0d |
| 132 | 1.16.4.7 | Etanchéité | 5d | 2011-10-18 | 2011-10-25 | 131 | 2011-10-18 | 2011-10-25 | 5d | 2011-10-18 | 2011-10-25 | 60d | 0d |
| 133 | 1.16.4.8 | Réseaux AEP, EP | 5d | 2011-10-25 | 2011-11-02 | 132 | 2011-10-25 | 2011-11-02 | 5d | 2011-10-25 | 2011-11-02 | 60d |  |

| ID | WBS | Task | Duration | Start | Finish | Predecessors | Baseline start | Baseline finish | Baseline duration | Baseline 1 start | Baseline 1 finish | Total slack | Free slack | Resources | Work |
| --- | --- | --- | --- | --- | --- | --- | --- | --- | --- | --- | --- | --- | --- | --- | --- |
| 134 | 1.17 | **FOSSES TRANSFORMATEURS ET M PARE FEU ET F. HUILE** | 110d | 2011-05-02 | 2011-10-24 | 70SS+28d | 2011-05-02 | 2011-10-24 | 110d | 2011-05-02 | 2011-10-24 | 66d | 0d | 1Pelle hydraulique, 1 Camion,10 Cof, 5 Maçon, 5 Fer, 8 MO | 880h |
| 135 | 1.17.1 | Terrassements et BP | 10d | 2011-05-02 | 2011-05-17 |  | 2011-05-02 | 2011-05-17 | 10d | 2011-05-02 | 2011-05-17 | 66d | 0d |  |  |
| 136 | 1.17.2 | **Semelles longrines** | 15d | 2011-05-17 | 2011-06-09 | 135 | 2011-05-17 | 2011-06-09 | 15d | 2011-05-17 | 2011-06-09 | 66d | 0d |  |  |
| 137 | 1.17.2.1 | Ferraillage | 7d | 2011-05-17 | 2011-05-27 |  | 2011-05-17 | 2011-05-27 | 7d | 2011-05-17 | 2011-05-27 | 66d | 0d |  |  |
| 138 | 1.17.2.2 | Coffrage | 7d | 2011-05-27 | 2011-06-08 | 137 | 2011-05-27 | 2011-06-08 | 7d | 2011-05-27 | 2011-06-08 | 66d | 0d |  |  |
| 139 | 1.17.2.3 | Bétonnage | 1d | 2011-06-08 | 2011-06-09 | 138 | 2011-06-08 | 2011-06-09 | 1d | 2011-06-08 | 2011-06-09 | 66d |  |  |  |
| 140 | 1.17.3 | **Longrines** | 15d | 2011-06-09 | 2011-07-04 | 136 | 2011-06-09 | 2011-07-04 | 15d | 2011-06-09 | 2011-07-04 | 66d | 0d |  |  |
| 141 | 1.17.3.1 | Ferraillage | 7d | 2011-06-09 | 2011-06-21 |  | 2011-06-09 | 2011-06-21 | 7d | 2011-06-09 | 2011-06-21 | 66d | 0d |  |  |
| 142 | 1.17.3.2 | Coffrage | 7d | 2011-06-21 | 2011-07-01 | 141 | 2011-06-21 | 2011-07-01 | 7d | 2011-06-21 | 2011-07-01 | 66d | 0d |  |  |
| 143 | 1.17.3.3 | Bétonnage | 1d | 2011-07-01 | 2011-07-04 | 142 | 2011-07-01 | 2011-07-04 | 1d | 2011-07-01 | 2011-07-04 | 66d |  |  |  |
| 144 | 1.17.4 | **Fosse à huile** | 15d | 2011-07-04 | 2011-07-27 | 140 | 2011-07-04 | 2011-07-27 | 15d | 2011-07-04 | 2011-07-27 | 66d | 0d |  |  |
| 145 | 1.17.4.1 | Hérisson et polyane | 2d | 2011-07-04 | 2011-07-06 |  | 2011-07-04 | 2011-07-06 | 2d | 2011-07-04 | 2011-07-06 | 66d | 0d |  |  |
| 146 | 1.17.4.2 | Ferraillage | 2d | 2011-07-07 | 2011-07-11 | 145 | 2011-07-07 | 2011-07-11 | 2d | 2011-07-07 | 2011-07-11 | 66d | 0d |  |  |
| 147 | 1.17.4.3 | Bétonnage | 1d | 2011-07-11 | 2011-07-12 | 146 | 2011-07-11 | 2011-07-12 | 1d | 2011-07-11 | 2011-07-12 | 66d | 0d |  |  |
| 148 | 1.17.4.4 | Murets | 10d | 2011-07-12 | 2011-07-27 | 147 | 2011-07-12 | 2011-07-27 | 10d | 2011-07-12 | 2011-07-27 | 66d |  |  |  |
| 149 | 1.17.5 | **Semelles mur pare feu** | 15d | 2011-07-27 | 2011-08-19 | 144 | 2011-07-27 | 2011-08-19 | 15d | 2011-07-27 | 2011-08-19 | 66d | 0d |  |  |
| 150 | 1.17.5.1 | Ferraillage | 7d | 2011-07-27 | 2011-08-08 |  | 2011-07-27 | 2011-08-08 | 7d | 2011-07-27 | 2011-08-08 | 66d | 0d |  |  |
| 151 | 1.17.5.2 | Coffrage | 7d | 2011-08-08 | 2011-08-18 | 150 | 2011-08-08 | 2011-08-18 | 7d | 2011-08-08 | 2011-08-18 | 66d | 0d |  |  |
| 152 | 1.17.5.3 | Bétonnage | 1d | 2011-08-18 | 2011-08-19 | 151 | 2011-08-18 | 2011-08-19 | 1d | 2011-08-18 | 2011-08-19 | 66d |  |  |  |
| 153 | 1.17.6 | **Mur pare feu : première levée** | 15d | 2011-08-22 | 2011-09-14 | 149 | 2011-08-22 | 2011-09-14 | 15d | 2011-08-22 | 2011-09-14 | 66d | 0d |  |  |
| 154 | 1.17.6.1 | Ferraillage | 7d | 2011-08-22 | 2011-08-31 |  | 2011-08-22 | 2011-08-31 | 7d | 2011-08-22 | 2011-08-31 | 66d | 0d |  |  |
| 155 | 1.17.6.2 | Coffrage | 7d | 2011-09-01 | 2011-09-12 | 154 | 2011-09-01 | 2011-09-12 | 7d | 2011-09-01 | 2011-09-12 | 66d | 0d |  |  |
| 156 | 1.17.6.3 | Bétonnage | 1d | 2011-09-13 | 2011-09-14 | 155 | 2011-09-13 | 2011-09-14 | 1d | 2011-09-13 | 2011-09-14 | 66d |  |  |  |
| 157 | 1.17.7 | **Mur pare feu : deuxième levée** | 15d | 2011-09-14 | 2011-10-07 | 153 | 2011-09-14 | 2011-10-07 | 15d | 2011-09-14 | 2011-10-07 | 66d | 0d |  |  |
| 158 | 1.17.7.1 | Ferraillage | 7d | 2011-09-14 | 2011-09-26 |  | 2011-09-14 | 2011-09-26 | 7d | 2011-09-14 | 2011-09-26 | 66d | 0d |  |  |
| 159 | 1.17.7.2 | Coffrage | 7d | 2011-09-26 | 2011-10-06 | 158 | 2011-09-26 | 2011-10-06 | 7d | 2011-09-26 | 2011-10-06 | 66d | 0d |  |  |
| 160 | 1.17.7.3 | Bétonnage | 1d | 2011-10-06 | 2011-10-07 | 159 | 2011-10-06 | 2011-10-07 | 1d | 2011-10-06 | 2011-10-07 | 66d |  |  |  |

| ID | WBS | Task | Duration | Start | Finish | Predecessors | Baseline start | Baseline finish | Baseline duration | Baseline 1 start | Baseline 1 finish | Total slack | Free slack | Resources | Work |
| --- | --- | --- | --- | --- | --- | --- | --- | --- | --- | --- | --- | --- | --- | --- | --- |
| 161 | 1.17.8 | **Finition fosses** | 10d | 2011-10-07 | 2011-10-24 | 157 | 2011-10-07 | 2011-10-24 | 10d | 2011-10-07 | 2011-10-24 | 66d |  |  |  |
| 162 | 1.17.8.1 | Pose des rails | 10d | 2011-10-07 | 2011-10-24 |  | 2011-10-07 | 2011-10-24 | 10d | 2011-10-07 | 2011-10-24 | 66d |  |  |  |
| 163 | 1.17.8.2 | Pose Métallerie | 3d | 2011-10-07 | 2011-10-12 |  | 2011-10-07 | 2011-10-12 | 3d | 2011-10-07 | 2011-10-12 | 73d |  |  |  |
| 164 | 1.17.8.3 | Drainage huile | 8d | 2011-10-07 | 2011-10-20 |  | 2011-10-07 | 2011-10-20 | 8d | 2011-10-07 | 2011-10-20 | 68d |  |  |  |
| 165 | 1.18 | **CANIVEAUX ET TRAVERSEES DE ROUTE** | 100d | 2011-05-24 | 2011-10-31 | 134SS+14d | 2011-05-24 | 2011-10-31 | 100d | 2011-05-24 | 2011-10-31 | 62d | 0d | 1 Rétro_chargeur, 1 Camion,3 Coffreurs, 1 Maçon, 3 MO | 800h |
| 166 | 1.18.1 | **Caniveaux** | 100d | 2011-05-24 | 2011-10-31 |  | 2011-05-24 | 2011-10-31 | 100d | 2011-05-24 | 2011-10-31 | 62d |  |  |  |
| 167 | 1.18.1.1 | Terrassement et BP | 13d | 2011-05-24 | 2011-06-13 |  | 2011-05-24 | 2011-06-13 | 13d | 2011-05-24 | 2011-06-13 | 62d | 0d |  |  |
| 168 | 1.18.1.2 | Ferraillage | 25d | 2011-06-13 | 2011-07-22 | 167 | 2011-06-13 | 2011-07-22 | 25d | 2011-06-13 | 2011-07-22 | 62d | 0d |  |  |
| 169 | 1.18.1.3 | Coffrage | 25d | 2011-07-22 | 2011-08-31 | 168 | 2011-07-22 | 2011-08-31 | 25d | 2011-07-22 | 2011-08-31 | 62d | 0d |  |  |
| 170 | 1.18.1.4 | Bétonnage | 22d | 2011-09-01 | 2011-10-06 | 169 | 2011-09-01 | 2011-10-06 | 22d | 2011-09-01 | 2011-10-06 | 62d | 0d |  |  |
| 171 | 1.18.1.5 | Pose corbeaux | 15d | 2011-10-06 | 2011-10-31 | 170 | 2011-10-06 | 2011-10-31 | 15d | 2011-10-06 | 2011-10-31 | 62d |  |  |  |
| 172 | 1.18.2 | **Ouvrages traversée de route** | 18d | 2011-05-24 | 2011-06-21 |  | 2011-05-24 | 2011-06-21 | 18d | 2011-05-24 | 2011-06-21 | 144d |  |  |  |
| 173 | 1.18.2.1 | Fouilles en tranchée | 5d | 2011-05-24 | 2011-05-31 |  | 2011-05-24 | 2011-05-31 | 5d | 2011-05-24 | 2011-05-31 | 144d | 0d |  |  |
| 174 | 1.18.2.2 | Coulage PVC | 7d | 2011-05-31 | 2011-06-10 | 173 | 2011-05-31 | 2011-06-10 | 7d | 2011-05-31 | 2011-06-10 | 144d | 0d |  |  |
| 175 | 1.18.2.3 | Remblais | 6d | 2011-06-10 | 2011-06-21 | 174 | 2011-06-10 | 2011-06-21 | 6d | 2011-06-10 | 2011-06-21 | 144d |  |  |  |
| 176 | 1.19 | **VOIES ET CHAUSSEES** | 60d | 2011-08-11 | 2011-11-15 | 165SS+50d | 2011-08-11 | 2011-11-15 | 60d | 2011-08-11 | 2011-11-15 | 31d | 0d |  | 1760h |
| 177 | 1.19.1 | **Voies légères** | 30d | 2011-08-11 | 2011-09-28 |  | 2011-08-11 | 2011-09-28 | 30d | 2011-08-11 | 2011-09-28 | 31d | 0d |  | 776h |
| 178 | 1.19.1.1 | Déblais | 5d | 2011-08-11 | 2011-08-18 |  | 2011-08-11 | 2011-08-18 | 5d | 2011-08-11 | 2011-08-18 | 31d | 0d | 2 Camions; 1 bulldozer; 1 Chargeur | 120h |
| 179 | 1.19.1.2 | Corps de chaussée | 20d | 2011-08-15 | 2011-09-15 | 178FS-3d | 2011-08-15 | 2011-09-15 | 20d | 2011-08-15 | 2011-09-15 | 31d | 0d | 2 Camions; 1 pelle hydraulique; 1 Niveleuse | 480h |
| 180 | 1.19.1.3 | Couche de roulement en béton | 22d | 2011-08-24 | 2011-09-28 | 179FS-14d | 2011-08-24 | 2011-09-28 | 22d | 2011-08-24 | 2011-09-28 | 31d |  | 1 Bétonnière, 2 Cof, 2 Maçons, 3MO | 176h |
| 181 | 1.19.2 | **Voies lourdes** | 30d | 2011-09-28 | 2011-11-15 | 177 | 2011-09-28 | 2011-11-15 | 30d | 2011-09-28 | 2011-11-15 | 31d |  |  | 776h |
| 182 | 1.19.2.1 | Déblais | 5d | 2011-09-28 | 2011-10-06 |  | 2011-09-28 | 2011-10-06 | 5d | 2011-09-28 | 2011-10-06 | 31d | 0d | 2 Camions; 1 bulldozer; 1 Chargeur | 120h |
| 183 | 1.19.2.2 | Corps de chaussée | 20d | 2011-09-30 | 2011-11-02 | 182FS-3d | 2011-09-30 | 2011-11-02 | 20d | 2011-09-30 | 2011-11-02 | 31d | 0d | 2 Camions; 1 pelle hydraulique; 1 Niveleuse | 480h |
| 184 | 1.19.2.3 | Couche de roulement en béton | 22d | 2011-10-11 | 2011-11-15 | 183FS-14d | 2011-10-11 | 2011-11-15 | 22d | 2011-10-11 | 2011-11-15 | 31d |  | 1 Bétonnière, 2 Cof, 2 Maçons, 3MO | 176h |
| 185 | 1.19.3 | Bordures de trottoirs | 26d | 2011-08-11 | 2011-09-21 |  | 2011-08-11 | 2011-09-21 | 26d | 2011-08-11 | 2011-09-21 | 65d |  | 2 Maçons, 3MO | 208h |

| ID | WBS | Task | Duration | Start | Finish | Predecessors | Baseline start | Baseline finish | Baseline duration | Baseline 1 start | Baseline 1 finish | Total slack | Free slack | Resources | Work |
| --- | --- | --- | --- | --- | --- | --- | --- | --- | --- | --- | --- | --- | --- | --- | --- |
| 186 | 1.20 | **ECLAIRAGE EXTERIEUR ET TELESURVEILLANCE** | 42d | 2011-10-12 | 2011-12-19 | 176FS-21d | 2011-10-12 | 2011-12-19 | 42d | 2011-10-12 | 2011-12-19 | 31d |  | 1 Bétonnière, 2 Cof, 2 Maçons, 3MO | 336h |
| 187 | 1.20.1 | ECLAIRAGE EXTERIEUR | 21d | 2011-10-12 | 2011-11-15 |  | 2011-10-12 | 2011-11-15 | 21d | 2011-10-12 | 2011-11-15 | 31d | 0d | 1 Bétonnière, 2 Cof, 2 Maçons, 3MO |  |
| 188 | 1.20.2 | TELESURVEILLANCE | 21d | 2011-11-15 | 2011-12-19 | 187 | 2011-11-15 | 2011-12-19 | 21d | 2011-11-15 | 2011-12-19 | 31d |  |  |  |
| 189 | 1.21 | **GRAVILLONAGE ET AMENGAGEMENT EXTERIEUR** | 102d | 2011-08-11 | 2012-01-20 | 176SS | 2011-08-11 | 2012-01-20 | 102d | 2011-08-11 | 2012-01-20 | 0d |  |  | 896h |
| 190 | 1.21.1 | Gravillonage | 10d | 2011-08-11 | 2011-08-26 |  | 2011-08-11 | 2011-08-26 | 10d | 2011-08-11 | 2011-08-26 | 92d |  | 1 Chargeur, 1 Epandeuse | 80h |
| 191 | 1.21.2 | Aménagement extérieur | 102d | 2011-08-11 | 2012-01-20 |  | 2011-08-11 | 2012-01-20 | 102d | 2011-08-11 | 2012-01-20 | 0d |  | 1 Rétro_chargeur, 1 Camion,1 Cof, 3 MO | 816h |
| 192 | 1.22 | Nettoyage et replis | 10d | 2012-01-20 | 2012-02-07 | 189 |  |  |  |  |  | 0d |  |  |  |
